# 2008Plan-1

Schedule from MS Project, 2008-05-21 to 2008-09-16, costs in $.
MBARI

## Calendars

- Standard: Mon-Fri 08:00-12:00, 13:00-17:00; Sat-Sun off.

## Resources

| Resource |
| --- |
| GM |
| EE |
| CE |

## Schedule

| ID | WBS | Task | Duration | Start | Finish | Predecessors | Total slack | Resources | Work |
| --- | --- | --- | --- | --- | --- | --- | --- | --- | --- |
| 1 | 1 | Free Floating ESP | 1d? | 2008-05-21 | 2008-05-21 |  | 84d |  |  |
| 2 | 2 | Develop basic and profiling mission profiles | 6.67d? | 2008-05-21 | 2008-05-29 |  | 0d | GM [30%] | 16h |
| 3 | 3 | **Develop concepts** | 1d? | 2008-05-29 | 2008-05-30 | 2 | 0d | GM [30%] | 18.4h |
| 4 | 3.1 | Mechanical and hydrodynamic calculations | 1d? | 2008-05-29 | 2008-05-30 |  | 0d |  | 16h |
| 5 | 4 | PDR | 3.33d? | 2008-05-30 | 2008-06-04 | 3 | 0d | GM [30%] | 8h |
| 6 | 5 | **Develop detailed bFFESP design** | 1d? | 2008-06-05 | 2008-06-05 | 5 | 0d | GM [30%] | 10.4h |
| 7 | 5.1 | EE | 1d? | 2008-06-05 | 2008-06-05 |  | 0d | EE | 8h |
| 8 | 6 | bFFESP CDR | 6.67d? | 2008-06-06 | 2008-06-16 | 6 | 0d | GM [30%] | 16h |
| 9 | 7 | **bFFESP Fabrication** | 3.33d? | 2008-06-16 | 2008-06-19 | 8 | 0d |  | 152h |
| 10 | 7.1 | ME | 3.33d? | 2008-06-16 | 2008-06-19 |  | 0d | GM [30%] | 8h |
| 11 | 7.2 | Shop | 1d? | 2008-06-16 | 2008-06-17 |  | 2.33d |  | 80h |
| 12 | 7.3 | ET | 1d? | 2008-06-16 | 2008-06-17 |  | 2.33d |  | 24h |
| 13 | 7.4 | MT | 1d? | 2008-06-16 | 2008-06-17 |  | 2.33d |  | 24h |
| 14 | 7.5 | EE | 1d? | 2008-06-16 | 2008-06-17 |  | 2.33d |  | 16h |
| 15 | 8 | **bFFESP integration** | 6.67d? | 2008-06-20 | 2008-06-30 | 9 | 0d |  | 64h |
| 16 | 8.1 | ME | 6.67d? | 2008-06-20 | 2008-06-30 |  | 0d | GM [30%] | 16h |
| 17 | 8.2 | EE | 1d? | 2008-06-20 | 2008-06-20 |  | 5.67d |  | 8h |
| 18 | 8.3 | ET | 1d? | 2008-06-20 | 2008-06-20 |  | 5.67d |  | 16h |
| 19 | 8.4 | MT | 1d? | 2008-06-20 | 2008-06-20 |  | 5.67d |  | 24h |
| 20 | 9 | bFFESP field engineering test | 16.67d? | 2008-06-30 | 2008-07-23 | 15 | 0d | GM [30%] | 40h |
| 21 | 10 | bFFESP local field science test | 1d? | 2008-07-23 | 2008-07-24 | 20 | 38.67d |  | 24h |
| 22 | 11 | **pFFESP detailed design** | 1d? | 2008-07-23 | 2008-07-24 | 20 | 0d |  | 24h |
| 23 | 11.1 | EE | 1d? | 2008-07-23 | 2008-07-24 |  | 0d | EE [300%] | 24h |
| 24 | 12 | pFFESP CDR | 1d? | 2008-07-24 | 2008-07-25 | 22 | 0d |  |  |

| ID | WBS | Task | Duration | Start | Finish | Predecessors | Total slack | Free slack | Resources | Work | Cost |
| --- | --- | --- | --- | --- | --- | --- | --- | --- | --- | --- | --- |
| 25 | 13 | **pFFESP Fabrication** | 3.33d? | 2008-07-25 | 2008-07-30 | 24 | 0d |  |  | 88h |  |
| 26 | 13.1 | ME | 3.33d? | 2008-07-25 | 2008-07-30 |  | 0d |  | GM [30%] | 8h |  |
| 27 | 13.2 | Shop | 1d? | 2008-07-25 | 2008-07-28 |  | 2.33d |  |  | 80h |  |
| 28 | 14 | pFFESP integration | 1d? | 2008-07-30 | 2008-07-31 | 25 | 0d |  | GM [30%] | 2.4h |  |
| 29 | 15 | pFFESP bench/tank test | 16.67d? | 2008-07-31 | 2008-08-25 | 28 | 0d |  | GM [30%] | 40h |  |
| 30 | 16 | pFFESP field test | 16.67d? | 2008-08-25 | 2008-09-16 | 29 | 0d |  | GM [30%] | 40h |  |
| 31 | 17 | HOTS field test prep | 1d? | 2008-05-21 | 2008-05-21 |  | 84d |  |  |  |  |
| 32 | 18 | HOTS field test support | 1d? | 2008-05-21 | 2008-05-21 |  | 84d |  |  |  |  |
| 33 | 19 | Float with subsurface structure | 1d? | 2008-05-21 | 2008-05-21 |  | 84d |  |  | 8h | 9,500 |
| 34 | 20 | Surface tower | 1d? | 2008-05-22 | 2008-05-22 |  | 83d |  |  | 8h | 1,000 |
| 35 | 21 | Cabling | 1d? | 2008-05-21 | 2008-05-21 |  | 84d |  |  |  | 2,500 |
| 36 | 22 | 2x motion sensor and data logger | 1d? | 2008-05-21 | 2008-05-21 |  | 84d |  |  |  | 3,000 |
| 37 | 23 | Standard ESP with DSP&L batteries and long E/M cable | 1d? | 2008-05-21 | 2008-05-21 |  | 84d |  |  |  |  |
| 38 | 24 | Iridium modem | 1d? | 2008-05-21 | 2008-05-21 |  | 84d |  |  |  | 1,750 |
| 39 | 25 | Iridium airtime (~$80/Mbyte) | 1d? | 2008-05-21 | 2008-05-21 |  | 84d |  |  |  | 4,000 |
| 40 | 26 | Benchtop profiling module | 1d? | 2008-05-21 | 2008-05-21 |  | 84d |  |  |  | 7,500 |
| 41 | 27 | Electrical slip ring | 1d? | 2008-05-21 | 2008-05-21 |  | 84d |  |  |  | 2,500 |
| 42 | 28 | 200m ESP Housing | 1d? | 2008-05-21 | 2008-05-21 |  | 84d |  |  |  | 20,000 |
| 44 | 29 | 200m ESP Sampling Front End | 1d? | 2008-05-21 | 2008-05-21 |  | 84d |  |  |  |  |
| 45 | 30 | Analysis of existing design | 2d | 2008-05-21 | 2008-05-22 |  | 27d | 0d |  |  |  |
| 46 | 31 | Develop design concepts | 5d | 2008-05-23 | 2008-05-29 | 45 | 27d | 0d |  |  |  |
| 47 | 32 | PDR | 1d | 2008-05-30 | 2008-05-30 | 46 | 27d | 0d |  |  |  |
| 48 | 33 | **Develop & test benchtop prototype** | 50d? | 2008-06-02 | 2008-08-08 | 47 | 27d |  |  | 200h | 9,500 |
| 49 | 33.1 | Shop | 1d? | 2008-06-02 | 2008-06-02 |  | 76d |  |  |  |  |
| 50 | 33.2 | ME | 50d? | 2008-06-02 | 2008-08-08 |  | 27d |  | GM [30%] | 120h |  |
| 51 | 33.3 | ME | 10d? | 2008-06-02 | 2008-06-13 |  | 67d |  | CE | 80h |  |
| 52 | 33.4 | Scientist | 1d? | 2008-06-02 | 2008-06-02 |  | 76d |  |  |  |  |
| 53 | 33.5 | Existing Core Materials | 1d? | 2008-06-02 | 2008-06-02 |  | 76d |  |  |  |  |
| 54 | 33.6 | New valves, pumps, tubing, fittings, etc. | 1d? | 2008-06-02 | 2008-06-02 |  | 76d |  |  |  | 9,500 |
