# ESPd

Schedule from MS Project, 2008-05-21 to 2008-11-26.
MBARI

## Calendars

- Standard: Mon-Fri 08:00-12:00, 13:00-17:00; Sat-Sun off.

## Resources

| Resource |
| --- |
| GM |
| EE |
| CE |
| Gene |
| Andy |
| Scott |
| ME |
| Mike |
| Jose |
| Shop |

## Schedule

| ID | WBS | Task | Duration | Start | Finish | Predecessors | Total slack | Free slack | Resources | Work |
| --- | --- | --- | --- | --- | --- | --- | --- | --- | --- | --- |
| 1 | 1 | ESP drifting | 1d? | 2008-05-21 | 2008-05-21 |  | 130d |  |  |  |
| 2 | 2 | Develop basic and profiling mission profiles | 6.67d? | 2008-05-21 | 2008-05-29 |  | 10d | 0d |  | 16h |
| 3 | 3 | **Develop concepts** | 1d? | 2008-05-29 | 2008-05-30 | 2 | 10d | 0d |  | 16h |
| 4 | 3.1 | Mechanical and hydrodynamic calculations | 1d? | 2008-05-29 | 2008-05-30 |  | 10d |  |  | 16h |
| 5 | 4 | Concept DR | 3.33d? | 2008-05-30 | 2008-06-04 | 3 | 10d | 0d |  | 8h |
| 6 | 5 | **Detailed ESPd design** | 40d? | 2008-06-05 | 2008-07-30 | 5 | 0d |  |  | 824h |
| 7 | 5.1 | ME | 25d? | 2008-06-05 | 2008-07-09 |  | 15d |  | Gene | 200h |
| 8 | 5.2 | NA | 8d? | 2008-06-05 | 2008-06-16 |  | 32d |  | Andy | 64h |
| 9 | 5.3 | EE | 25d? | 2008-06-05 | 2008-07-09 |  | 15d |  | Scott | 200h |
| 10 | 5.4 | Control algorithm | 15d? | 2008-07-10 | 2008-07-30 |  | 0d |  | Gene | 120h |
| 11 | 5.5 | 200m ESP housing | 30d? | 2008-06-05 | 2008-07-16 |  | 10d |  | ME | 240h |
| 12 | 6 | **ESPd Fabrication** | 15d? | 2008-07-31 | 2008-08-20 | 6 | 0d |  |  | 336h |
| 13 | 6.1 | ME | 2d? | 2008-08-01 | 2008-08-04 |  | 12d |  | Gene | 16h |
| 14 | 6.2 | Shop | 15d? | 2008-07-31 | 2008-08-20 |  | 0d |  | Shop | 120h |
| 15 | 6.3 | MT | 10d? | 2008-07-31 | 2008-08-13 |  | 5d |  | Mike | 80h |
| 16 | 6.4 | EE | 5d? | 2008-07-31 | 2008-08-06 |  | 10d |  | Scott | 40h |
| 17 | 6.5 | ET | 10d? | 2008-07-31 | 2008-08-13 |  | 5d |  | Jose | 80h |
| 18 | 7 | **ESPd integration** | 10d? | 2008-08-21 | 2008-09-03 | 12 | 0d |  |  | 200h |
| 19 | 7.1 | ME | 5d? | 2008-08-21 | 2008-08-27 |  | 5d |  | Gene | 40h |
| 20 | 7.2 | EE | 10d? | 2008-08-21 | 2008-09-03 |  | 0d |  | Scott | 80h |
| 21 | 7.3 | ET | 5d? | 2008-08-21 | 2008-08-27 |  | 5d |  | Jose | 40h |
| 22 | 7.4 | MT | 5d? | 2008-08-21 | 2008-08-27 |  | 5d |  | Mike | 40h |
| 23 | 8 | **ESPd lab/tank test** | 15d? | 2008-09-04 | 2008-09-24 | 18 | 0d |  |  | 160h |
| 24 | 8.1 | ME | 15d? | 2008-09-04 | 2008-09-24 |  | 0d |  | Gene | 120h |
| 25 | 8.2 | EE | 5d? | 2008-09-04 | 2008-09-10 |  | 10d |  | Scott | 40h |

| ID | WBS | Task | Duration | Start | Finish | Predecessors | Total slack | Resources | Work |
| --- | --- | --- | --- | --- | --- | --- | --- | --- | --- |
| 26 | 9 | **ESPd field engineering test** | 10d? | 2008-09-25 | 2008-10-08 | 23 | 0d |  | 152h |
| 27 | 9.1 | ME | 5d? | 2008-09-25 | 2008-10-01 |  | 5d | Gene | 40h |
| 28 | 9.2 | EE | 10d? | 2008-09-25 | 2008-10-08 |  | 0d | Scott | 80h |
| 29 | 9.3 | Ship days | 1d? | 2008-09-25 | 2008-09-25 |  | 9d |  | 32h |
| 30 | 10 | **ESPd local field science test** | 5d? | 2008-10-09 | 2008-10-15 | 26 | 0d |  | 80h |
| 31 | 10.1 | ME | 5d? | 2008-10-09 | 2008-10-15 |  | 0d | Gene | 40h |
| 32 | 10.2 | EE | 2d? | 2008-10-09 | 2008-10-10 |  | 3d | Scott | 16h |
| 33 | 10.3 | Ship days | 1d? | 2008-10-09 | 2008-10-09 |  | 4d |  | 24h |
| 34 | 11 | **HOTS field test prep** | 10d? | 2008-10-16 | 2008-10-29 | 30 | 0d |  | 120h |
| 35 | 11.1 | ME | 10d? | 2008-10-16 | 2008-10-29 |  | 0d | Gene | 80h |
| 36 | 11.2 | EE | 5d? | 2008-10-16 | 2008-10-22 |  | 5d | Scott | 40h |
| 37 | 12 | **HOTS field test support** | 20d? | 2008-10-30 | 2008-11-26 | 34 | 0d |  | 168h |
| 38 | 12.1 | ME | 20d? | 2008-10-30 | 2008-11-26 |  | 0d | Gene | 160h |
| 39 | 12.2 | EE | 1d? | 2008-10-30 | 2008-10-30 |  | 19d | Scott | 8h |
