# ESPprofiler2010Ver1

Schedule from MS Project, 2010-01-18 to 2010-09-20, costs in $.
MBARI

## Calendars

- Standard: Mon-Fri 08:00-12:00, 13:00-17:00; Sat-Sun off.

## Resources

| Resource |
| --- |
| GM |
| EE |
| CE |
| Shop |
| Jose |
| Gene |
| Scott |
| Paul |
| Wayne |

## Schedule

| ID | WBS | Task | Duration | Start | Finish | Predecessors | Total slack | Free slack | Resources | Work | Cost |
| --- | --- | --- | --- | --- | --- | --- | --- | --- | --- | --- | --- |
| 1 | 1 | ESP Profiler | 1d? | 2010-01-18 | 2010-01-18 |  | 175d |  |  |  |  |
| 2 | 2 | Finish preliminary testing and analysis | 10d? | 2010-01-18 | 2010-01-29 |  | 65d | 0d | Gene | 80h |  |
| 3 | 3 | Prep for at sea test | 2d? | 2010-02-01 | 2010-02-02 | 2 | 64d | 0d | Gene; Paul | 32h |  |
| 4 | 4 | Sea test | 1d? | 2010-02-03 | 2010-02-03 | 3 | 64d | 0d | Gene; Paul; Scott | 24h |  |
| 5 | 5 | **Mechanical Design** | 7d? | 2010-02-04 | 2010-02-12 | 4 | 67d | 0d | Gene | 112h |  |
| 6 | 5.1 | motor mount | 3d? | 2010-02-04 | 2010-02-08 |  | 67d | 0d | Gene | 24h |  |
| 7 | 5.2 | buoy | 2d? | 2010-02-09 | 2010-02-10 | 6 | 67d | 0d | Gene | 16h |  |
| 8 | 5.3 | frame | 2d? | 2010-02-11 | 2010-02-12 | 7 | 67d |  | Gene | 16h |  |
| 9 | 6 | **Electrical Design** | 5d? | 2010-02-15 | 2010-02-19 | 5 | 67d | 0d | Scott | 80h |  |
| 10 | 6.1 | HV Design | 5d? | 2010-02-15 | 2010-02-19 |  | 67d |  | Scott | 40h |  |
| 11 | 7 | Mechanical Fab | 15d? | 2010-02-22 | 2010-03-12 | 5, 9 | 67d | 3d | Shop | 120h |  |
| 12 | 8 | Electrical Fab | 10d? | 2010-02-22 | 2010-03-05 | 5, 9 | 72d | 8d | Jose | 80h |  |
| 13 | 9 | Software Design | 30d? | 2010-02-04 | 2010-03-17 | 4 | 64d | 0d | Wayne | 240h |  |
| 14 | 10 | **test** | 60d? | 2010-03-18 | 2010-06-09 | 4, 9, 11, 12, 13 | 64d | 0d |  | 1480h |  |
| 15 | 10.1 | Gene | 60d? | 2010-03-18 | 2010-06-09 |  | 64d |  | Gene | 480h |  |
| 16 | 10.2 | Scott | 30d? | 2010-03-18 | 2010-04-28 |  | 94d |  | Scott | 240h |  |
| 17 | 10.3 | Paul | 45d? | 2010-03-18 | 2010-05-19 |  | 79d |  | Paul | 360h |  |
| 18 | 10.4 | Wayne | 50d? | 2010-03-18 | 2010-05-26 |  | 74d |  | Wayne | 400h |  |
| 20 | 11 | **Materials** | 2d? | 2010-01-18 | 2010-01-19 |  | 174d |  |  | 56h | 60,750 |
| 21 | 11.1 | Shana Rae Days | 1d? | 2010-01-18 | 2010-01-18 |  | 175d |  |  | 40h | 6,000 |
| 22 | 11.2 | New Buoy | 1d? | 2010-01-18 | 2010-01-18 |  | 175d |  |  | 8h | 12,000 |
| 23 | 11.3 | New frame | 1d? | 2010-01-19 | 2010-01-19 |  | 174d |  |  | 8h | 3,000 |
| 24 | 11.4 | New Motor | 1d? | 2010-01-18 | 2010-01-18 |  | 175d |  |  |  | 12,000 |
| 25 | 11.5 | Iridium modem | 1d? | 2010-01-18 | 2010-01-18 |  | 175d |  |  |  | 1,750 |
| 26 | 11.6 | Iridium airtime (~$80/Mbyte) | 1d? | 2010-01-18 | 2010-01-18 |  | 175d |  |  |  | 4,000 |
| 27 | 11.7 | Misc Mechanical | 1d? | 2010-01-18 | 2010-01-18 |  | 175d |  |  |  | 2,500 |
| 28 | 11.8 | Misc Electrical | 1d? | 2010-01-18 | 2010-01-18 |  | 175d |  |  |  | 2,500 |
| 29 | 11.9 | Misc Misc | 1d? | 2010-01-18 | 2010-01-18 |  | 175d |  |  |  | 5,000 |
| 30 | 11.10 | Batteries | 1d? | 2010-01-18 | 2010-01-18 |  | 175d |  |  |  | 12,000 |

| ID | WBS | Task | Duration | Start | Finish | Predecessors | Total slack | Constraint |
| --- | --- | --- | --- | --- | --- | --- | --- | --- |
| 32 | 12 | **Prep for cruise** | 1d? | 2010-06-10 | 2010-06-10 | 14 | 64d |  |
| 33 | 12.1 | Gene | 1d? | 2010-06-10 | 2010-06-10 |  | 64d |  |
| 34 | 12.2 | Paul | 1d? | 2010-06-10 | 2010-06-10 |  | 64d |  |
| 35 | 12.3 | Scott | 1d? | 2010-06-10 | 2010-06-10 |  | 64d |  |
| 36 | 12.4 | Wayne | 1d? | 2010-06-10 | 2010-06-10 |  | 64d |  |
| 38 | 13 | CANON cruise | 8d? | 2010-09-09 | 2010-09-20 | 32 | 0d | must start on 2010-09-09 |
