# Profiler2010

Schedule from MS Project, 2010-02-22 to 2010-09-07, costs in $.
MBARI

## Calendars

- Standard: Mon-Fri 08:00-12:00, 13:00-17:00; Sat-Sun off.

## Resources

| Resource |
| --- |
| Gene |
| Andy |
| EE |
| eTech |
| Wayne |
| Shop |
| Paul C. |
| mTech |

## Schedule

| ID | WBS | Task | Type | Duration | Start | Finish | Predecessors | Total slack | Free slack | Constraint | Resources | Work |
| --- | --- | --- | --- | --- | --- | --- | --- | --- | --- | --- | --- | --- |
| 1 | 1 | Define Requirements |  | 10d? | 2010-02-22 | 2010-03-05 |  | 131.05d | 0d |  | Gene [30%] | 24h |
| 2 | 2 | Consensus requirements | milestone | 0d | 2010-03-05 | 2010-03-05 | 1 | 127.91d |  |  |  |  |
| 3 | 3 | Project Go |  | 1d? | 2010-03-24 | 2010-03-24 |  | 0d |  | must start on 2010-03-24 |  |  |
| 5 | 4 | **Analysis** |  | 50d? | 2010-02-22 | 2010-05-03 |  | 37.86d |  |  |  | 136h |
| 6 | 4.1 | WHOI Cable |  | 7.14d | 2010-04-14 | 2010-04-26 | 15 | 0d |  |  | Gene [70%] | 40h |
| 7 | 4.2 | Add'l analysis |  | 2.86d | 2010-02-22 | 2010-02-24 |  | 133.19d | 42.14d |  | Gene [70%] | 16h |
| 8 | 4.3 | Review results |  | 5d? | 2010-04-26 | 2010-05-03 | 6, 7 | 91.05d |  |  | Andy | 40h |
| 9 | 4.4 | Ongoing analysis |  | 50d? | 2010-02-22 | 2010-04-30 |  | 91.05d |  |  | Gene [10%] | 40h |
| 11 | 5 | **Mechanical Design** |  | 14.86d? | 2010-03-25 | 2010-04-14 |  | 0d |  |  |  | 152h |
| 12 | 5.1 | Heavy Frame |  | 5.71d | 2010-03-25 | 2010-04-01 | 3 | 0d |  |  | Gene [70%] | 32h |
| 13 | 5.2 | New lower frame |  | 7.14d | 2010-04-01 | 2010-04-12 | 12 | 0d |  |  | Gene [70%] | 40h |
| 14 | 5.3 | Load cell bracket |  | 1d? | 2010-04-12 | 2010-04-13 | 13 | 0d |  |  |  | 40h |
| 15 | 5.4 | Structural analysis |  | 1d? | 2010-04-13 | 2010-04-14 | 14 | 0d |  |  |  | 40h |
| 17 | 6 | **Clean up elex box** |  | 13.43d | 2010-02-22 | 2010-03-11 |  | 68d |  |  |  | 72h |
| 18 | 6.1 | Gene |  | 1.43d | 2010-02-22 | 2010-02-23 |  | 68d | 0d |  | Gene [70%] | 8h |
| 19 | 6.2 | eTech |  | 12d | 2010-02-23 | 2010-03-11 | 18 | 68d |  |  | eTech [66.7%] | 64h |
| 21 | 7 | Design Review |  | 1.43d? | 2010-04-26 | 2010-04-27 | 11, 6 | 0d |  |  | Gene [70%]; Wayne [70%]; EE [70%] | 24h |
| 23 | 8 | Fabricate |  | 30d | 2010-05-04 | 2010-06-15 | 21FS+5d | 0d |  |  | Shop | 240h |
| 25 | 9 | **Integrate** |  | 5.71d? | 2010-06-15 | 2010-06-23 | 19, 23 | 0d |  |  |  | 88h |
| 26 | 9.1 | GM |  | 5d? | 2010-06-15 | 2010-06-22 |  | 0.71d |  |  | Gene [40%] | 16h |
| 27 | 9.2 | PC |  | 5.71d? | 2010-06-15 | 2010-06-23 |  | 0d |  |  | Paul C. [70%] | 32h |
| 28 | 9.3 | EE |  | 5d? | 2010-06-15 | 2010-06-22 |  | 0.71d |  |  | EE | 40h |
| 30 | 10 | **Test** |  | 39.57d? | 2010-06-23 | 2010-08-17 |  | 0d |  |  |  | 272h |
| 31 | 10.1 | **Tank test** |  | 7.14d? | 2010-06-23 | 2010-07-02 | 25 | 0d |  |  |  | 72h |
| 32 | 10.1.1 | GM |  | 7.14d? | 2010-06-23 | 2010-07-02 |  | 0d |  |  | Gene [70%] | 40h |
| 33 | 10.1.2 | PC |  | 3.33d | 2010-06-23 | 2010-06-28 |  | 3.81d |  |  | Paul C. [60%] | 16h |
| 34 | 10.1.3 | EE |  | 2d | 2010-06-23 | 2010-06-25 |  | 5.14d |  |  | EE | 16h |

| ID | WBS | Task | Duration | Start | Finish | Predecessors | Total slack | Resources | Work | Cost |
| --- | --- | --- | --- | --- | --- | --- | --- | --- | --- | --- |
| 35 | 10.2 | **Shana Rae 1** | 7.14d? | 2010-07-09 | 2010-07-20 | 31FS+5d | 0d |  | 64h |  |
| 36 | 10.2.1 | GM | 7.14d? | 2010-07-09 | 2010-07-20 |  | 0d | Gene [70%] | 40h |  |
| 37 | 10.2.2 | PC | 3.33d | 2010-07-09 | 2010-07-14 |  | 3.81d | Paul C. [60%] | 16h |  |
| 38 | 10.2.3 | EE | 1d? | 2010-07-09 | 2010-07-12 |  | 6.14d | EE | 8h |  |
| 39 | 10.3 | **Shana Rae 2** | 7.14d? | 2010-07-23 | 2010-08-03 | 35FS+3d | 0d |  | 72h |  |
| 40 | 10.3.1 | GM | 7.14d? | 2010-07-23 | 2010-08-03 |  | 0d | Gene [70%] | 40h |  |
| 41 | 10.3.2 | PC | 3d? | 2010-07-23 | 2010-07-28 |  | 4.14d | Paul C. | 24h |  |
| 42 | 10.3.3 | EE | 1d? | 2010-07-23 | 2010-07-26 |  | 6.14d | EE | 8h |  |
| 43 | 10.4 | **Shana Rae 3** | 7.14d? | 2010-08-06 | 2010-08-17 | 39FS+3d | 0d |  | 64h |  |
| 44 | 10.4.1 | GM | 7.14d? | 2010-08-06 | 2010-08-17 |  | 0d | Gene [70%] | 40h |  |
| 45 | 10.4.2 | PC | 3.33d | 2010-08-06 | 2010-08-11 |  | 3.81d | Paul C. [60%] | 16h |  |
| 46 | 10.4.3 | EE | 1d? | 2010-08-06 | 2010-08-09 |  | 6.14d | EE | 8h |  |
| 48 | 11 | mTech | 28.57d | 2010-07-02 | 2010-08-11 | 31 | 18.19d | mTech [35%] | 80h |  |
| 49 | 12 | eTech | 28.57d? | 2010-07-02 | 2010-08-11 | 31 | 18.19d | eTech [35%] | 80h |  |
| 51 | 13 | Readiness Review | 2.86d? | 2010-08-03 | 2010-08-06 | 39 | 21.62d | Gene [70%] | 16h |  |
| 53 | 14 | **W/F Cruise prep** | 3.33d? | 2010-08-17 | 2010-08-23 | 43 | 0d |  | 32h |  |
| 54 | 14.1 | GM | 2.86d? | 2010-08-17 | 2010-08-20 |  | 0.48d | Gene [70%] | 16h |  |
| 55 | 14.2 | PC | 3.33d | 2010-08-17 | 2010-08-23 |  | 0d | Paul C. [60%] | 16h |  |
| 57 | 15 | **W/F Cruise earliest** | 11d? | 2010-08-23 | 2010-09-07 | 53 | 0d |  | 88h |  |
| 58 | 15.1 | GM | 11d? | 2010-08-23 | 2010-09-07 |  | 0d | Gene | 88h |  |
| 60 | 16 | **Materials** | 1d? | 2010-02-22 | 2010-02-22 |  | 140.05d |  |  | 67,100 |
| 61 | 16.1 | Steel shapes | 1d? | 2010-02-22 | 2010-02-22 |  | 140.05d |  |  | 500 |
| 62 | 16.2 | Steel/lead weight plates | 1d? | 2010-02-22 | 2010-02-22 |  | 140.05d |  |  | 1,500 |
| 63 | 16.3 | Motor mount alum | 1d? | 2010-02-22 | 2010-02-22 |  | 140.05d |  |  | 500 |
| 64 | 16.4 | 110 size winch motor | 1d? | 2010-02-22 | 2010-02-22 |  | 140.05d |  |  | 15,000 |
| 65 | 16.5 | Motor controller | 1d? | 2010-02-22 | 2010-02-22 |  | 140.05d |  |  | 5,000 |
| 66 | 16.6 | Batteries | 1d? | 2010-02-22 | 2010-02-22 |  | 140.05d |  |  | 8,000 |
| 67 | 16.7 | Shana Rae days | 1d? | 2010-02-22 | 2010-02-22 |  | 140.05d |  |  | 3,600 |
| 68 | 16.8 | New load cells | 1d? | 2010-02-22 | 2010-02-22 |  | 140.05d |  |  | 10,000 |
| 69 | 16.9 | Misc | 1d? | 2010-02-22 | 2010-02-22 |  | 140.05d |  |  | 7,500 |
| 70 | 16.10 | Ethernet modems | 1d? | 2010-02-22 | 2010-02-22 |  | 140.05d |  |  | 5,000 |
| 71 | 16.11 | Frame for bigger buoy | 1d? | 2010-02-22 | 2010-02-22 |  | 140.05d |  |  | 2,500 |
| 72 | 16.12 | New electronics | 1d? | 2010-02-22 | 2010-02-22 |  | 140.05d |  |  | 4,500 |
| 73 | 16.13 | Brake | 1d? | 2010-02-22 | 2010-02-22 |  | 140.05d |  |  | 3,500 |
