# Q3-4 2009 Plan

Schedule from MS Project, 2009-06-29 to 2009-09-16.
MBARI

## Calendars

- Standard: Mon-Fri 08:00-12:00, 13:00-17:00; Sat-Sun off.

## Resources

| Resource |
| --- |
| Jim S. |
| Gene |
| Paul |
| Mike |
| Scott |
| Wayne |
| Tom |

## Schedule

| ID | WBS | Task | Duration | Start | Finish | Predecessors | Total slack | Resources | Work |
| --- | --- | --- | --- | --- | --- | --- | --- | --- | --- |
| 1 | 1 | **ESP Profiler Tension Control Deployment** | 58d? | 2009-06-29 | 2009-09-16 |  | 0d |  | 484h |
| 2 | 1.1 | Write tension control (TC) algorithm, desk test | 10d | 2009-06-29 | 2009-07-10 |  | 6.83d | Gene [30%] | 24h |
| 3 | 1.2 | Heat treat motor mount | 10d | 2009-06-29 | 2009-07-10 |  | 6.33d | Mike [10%] | 8h |
| 4 | 1.3 | **Repackage electronics in bigger box** | 13.33d | 2009-06-29 | 2009-07-16 |  | 0d |  | 88h |
| 5 | 1.3.1 | Gene | 5d | 2009-06-29 | 2009-07-03 |  | 11.33d | Gene [20%] | 8h |
| 6 | 1.3.2 | Etechs | 13.33d | 2009-06-29 | 2009-07-16 | 5 | 0d | Tom [60%] | 64h |
| 7 | 1.3.3 | Mike P. | 2d | 2009-06-29 | 2009-06-30 |  | 14.33d | Mike | 16h |
| 8 | 1.4 | Move existing "wave simulator" into test tank | 2d? | 2009-07-16 | 2009-07-20 | 6 | 0d | Jim S. | 16h |
| 9 | 1.5 | Rig wave simulator and profiler | 1d? | 2009-07-20 | 2009-07-21 | 8 | 0d | Gene; Paul | 16h |
| 10 | 1.6 | Resetup development station and get original program running | 0.5d | 2009-07-21 | 2009-07-21 | 9, 4, 3 | 0d | Gene | 4h |
| 11 | 1.7 | Initial TC tests in tank | 4d | 2009-07-21 | 2009-07-27 | 10, 2 | 0d | Gene [50%] | 16h |
| 12 | 1.8 | Test/modify TC algorithm | 16d | 2009-07-27 | 2009-08-18 | 11 | 0d | Gene [50%] | 64h |
| 13 | 1.9 | Test loss of link code | 2d | 2009-08-18 | 2009-08-20 | 12 | 0d | Wayne | 16h |
| 14 | 1.10 | End to end system testing | 7.5d | 2009-08-20 | 2009-09-01 | 13 | 0d | Gene [40%]; Wayne [40%] | 48h |
| 15 | 1.11 | Prep for deployment | 4d | 2009-09-01 | 2009-09-07 | 14 | 0d | Gene [50%]; Paul [50%] | 32h |
| 16 | 1.12 | Deployment | 1d | 2009-09-07 | 2009-09-08 | 15 | 0d | Gene; Paul; Scott | 24h |
| 17 | 1.13 | Prepare results | 6.67d | 2009-09-08 | 2009-09-16 | 16 | 0d | Gene [30%] | 16h |
| 19 | 1.14 | **Misc tasks** | 40d | 2009-06-29 | 2009-08-21 |  | 18d |  | 112h |
| 20 | 1.14.1 | Gene | 40d | 2009-06-29 | 2009-08-21 |  | 18d | Gene [15%] | 48h |
| 21 | 1.14.2 | Mike | 26.67d | 2009-06-29 | 2009-08-04 |  | 31.33d | Mike [15%] | 32h |
| 22 | 1.14.3 | Paul | 26.67d | 2009-06-29 | 2009-08-04 |  | 31.33d | Paul [15%] | 32h |
